# 07I&T

Schedule from MS Project, 2007-01-03 to 2007-10-02.
MBARI

## Calendars

- Standard: Mon-Fri 08:00-12:00, 13:00-17:00; Sat-Sun off.

## Resources

| Resource |
| --- |
| UW |
| MBARI |
| WHOI |
| MBARI(Ed) |
| Ed |
| Gene |

## Schedule

| ID | WBS | Task | Duration | Start | Finish | Predecessors | Total slack | Free slack | Constraint | Resources | Work |
| --- | --- | --- | --- | --- | --- | --- | --- | --- | --- | --- | --- |
| 1 | 1 | **LV Subsystem** | 23d | 2007-01-12 | 2007-02-13 |  | 52d |  |  |  | 88h |
| 2 | 1.1 | LV FAT @ UW | 1d | 2007-01-12 | 2007-01-12 |  | 52d | 0d | finish no earlier than 2007-01-12 | UW | 8h |
| 3 | 1.2 | Shipping UW to MBARI | 5d | 2007-01-15 | 2007-01-19 | 2 | 74d | 0d | finish no earlier than 2007-01-19 | UW | 40h |
| 4 | 1.3 | Setup and initial test at MBARI | 2d | 2007-01-22 | 2007-01-23 | 3 | 74d | 0d |  | UW | 16h |
| 5 | 1.4 | Final Dry/Wet Chassis flight checkout | 4d | 2007-01-24 | 2007-01-29 | 4 | 92d | 0d |  |  |  |
| 6 | 1.5 | Complete any identified mods | 3d | 2007-01-30 | 2007-02-01 | 5 | 63d | 0d |  |  |  |
| 7 | 1.6 | Perform subset of FAT | 3d | 2007-02-02 | 2007-02-06 | 6 | 63d | 0d |  | UW | 24h |
| 8 | 1.7 | Contingency | 5d | 2007-02-07 | 2007-02-13 | 7 | 63d | 0d |  |  |  |
| 10 | 2 | **LV/DCS Integration** | 34d | 2007-01-24 | 2007-03-12 |  | 67d |  |  |  | 96h |
| 11 | 2.1 | Integrate LV/DCS and initial test | 1d | 2007-01-24 | 2007-01-24 | 4 | 129d |  |  | UW; MBARI | 16h |
| 12 | 2.2 | DCS back to speed | 3d | 2007-02-14 | 2007-02-16 | 8 | 63d | 0d | finish no earlier than 2007-01-05 | WHOI [33.3%]; MBARI [33.3%] | 16h |
| 13 | 2.3 | Complete any identified mods | 3d | 2007-02-19 | 2007-02-21 | 12 | 63d | 0d |  |  |  |
| 14 | 2.4 | DCS FAT | 5d | 2007-02-22 | 2007-02-28 | 13 | 63d | 0d |  | WHOI | 40h |
| 15 | 2.5 | Can it | 3d | 2007-03-01 | 2007-03-05 | 14 | 63d | 0d |  | MBARI [33.3%] | 8h |
| 16 | 2.6 | test | 5d | 2007-03-06 | 2007-03-12 | 15 | 63d | 0d |  | MBARI [20%]; WHOI [20%] | 16h |
| 18 | 3 | **MV Converter** | 185d | 2007-01-03 | 2007-09-18 |  | 10d |  |  | MBARI | 1808h |
| 19 | 3.1 | Proto arrives at MBARI | 1d | 2007-07-23 | 2007-07-23 |  | 0d |  | start no earlier than 2007-07-23 |  |  |
| 20 | 3.2 | Initial setup & test | 3d | 2007-07-24 | 2007-07-26 | 19 | 48d |  |  | Ed [166.7%]; Gene [166.7%] | 80h |
| 21 | 3.3 | Build temp FC77 can | 3d | 2007-01-03 | 2007-01-05 |  | 142d |  |  | Ed; Gene [41.9%] | 16h |
| 22 | 3.4 | Build up temp test fixture | 1d | 2007-01-03 | 2007-01-03 |  | 96d | 31d |  | Gene [225%]; Ed | 24h |
| 23 | 3.5 | Install temper. sensors & test | 3d | 2007-07-24 | 2007-07-26 | 22, 19 | 0d |  |  |  |  |
| 24 | 3.6 | Test | 15d | 2007-07-27 | 2007-08-16 | 19, 23 | 0d |  |  | Ed [33.3%] | 40h |
| 25 | 3.7 | Final arrives at MBARI | 1d | 2007-08-17 | 2007-08-17 | 24 | 5d | 0d | finish no earlier than 2007-06-15 |  |  |
| 26 | 3.8 | Initial setup & test | 3d | 2007-08-20 | 2007-08-22 | 25 | 5d | 0d |  | Ed; Gene | 48h |
| 27 | 3.9 | Replace bench supply with MV Conv. | 2d | 2007-08-23 | 2007-08-24 | 26 | 5d | 0d |  | Ed; Gene | 32h |
| 28 | 3.10 | Testing | 10d | 2007-08-27 | 2007-09-07 | 27 | 5d | 0d |  | Ed [16.7%]; UW | 16h |
| 29 | 3.11 | Clean & Can it | 2d | 2007-09-10 | 2007-09-11 | 28 | 5d | 0d |  | Ed; Gene | 32h |
| 30 | 3.12 | Test | 5d | 2007-09-12 | 2007-09-18 | 29 | 5d |  |  | Ed | 40h |

| ID | WBS | Task | Duration | Start | Finish | Predecessors | Total slack | Free slack | Resources | Work |
| --- | --- | --- | --- | --- | --- | --- | --- | --- | --- | --- |
| 32 | 4 | **System Testing** | 195d | 2007-01-03 | 2007-10-02 |  | 0d |  | MBARI | 1576h |
| 33 | 4.1 | Safely setup 10 kV PS | 2d | 2007-01-03 | 2007-01-04 |  | 143d |  | Ed | 16h |
| 34 | 4.2 | Lab tests | 8d | 2007-03-13 | 2007-03-22 | 16 | 52d | 0d |  |  |
| 35 | 4.3 | Build up science node w/Proto MV Conv (maybe) | 3d | 2007-03-23 | 2007-03-27 | 34 | 52d | 0d |  |  |
| 36 | 4.4 | Tank test w/Proto (maybe) | 10d | 2007-08-17 | 2007-08-30 | 24, 35 | 0d |  |  |  |
| 37 | 4.5 | Build up science node w/Final MV Conv | 3d | 2007-08-31 | 2007-09-04 | 36 | 0d |  |  |  |
| 38 | 4.6 | Tank test w/Final | 10d | 2007-09-05 | 2007-09-18 | 37 | 0d |  |  |  |
| 39 | 4.7 | Add'l tests | 5d | 2007-09-19 | 2007-09-25 | 38 | 0d |  |  |  |
| 40 | 4.8 | Pre-installation testing | 5d | 2007-09-26 | 2007-10-02 | 39, 30 | 0d |  |  |  |
| 42 | 5 | **Shore Station** | 5d? | 2007-01-03 | 2007-01-09 |  | 140d |  | MBARI | 144h |
| 43 | 5.1 | Existing Ground Farm test | 1d? | 2007-01-03 | 2007-01-03 |  | 144d |  |  |  |
| 44 | 5.2 | Specify new ground rod locations | 1d? | 2007-01-03 | 2007-01-03 |  | 143d | 0d |  |  |
| 45 | 5.3 | Ground Farm re-install & test | 1d? | 2007-01-04 | 2007-01-04 | 44 | 143d |  |  |  |
| 46 | 5.4 | **MV safety/switching panel** | 1d? | 2007-01-03 | 2007-01-03 |  | 144d |  |  |  |
| 47 | 5.4.1 | Design | 1d? | 2007-01-03 | 2007-01-03 |  | 144d |  |  |  |
| 48 | 5.4.2 | Build | 1d? | 2007-01-03 | 2007-01-03 |  | 144d |  |  |  |
| 49 | 5.4.3 | Test | 1d? | 2007-01-03 | 2007-01-03 |  | 144d |  |  |  |
| 50 | 5.5 | Build up MV rack | 1d? | 2007-01-03 | 2007-01-03 |  | 144d |  | UW; MBARI | 16h |
| 51 | 5.6 | Build up DCS rack | 1d? | 2007-01-03 | 2007-01-03 |  | 144d |  | MBARI | 8h |
| 52 | 5.7 | **Shore station testing** | 5d | 2007-01-03 | 2007-01-09 |  | 140d |  |  | 80h |
| 53 | 5.7.1 | General testing | 5d | 2007-01-03 | 2007-01-09 |  | 140d |  |  |  |
| 54 | 5.7.2 | MV/? Monitoring | 5d | 2007-01-03 | 2007-01-09 |  | 140d |  | UW; MBARI | 80h |
| 56 | 6 | **Commissioning** | 1d? | 2007-01-03 | 2007-01-03 |  | 144d |  |  |  |
| 57 | 6.1 | Install SIIM/ADCP | 1d? | 2007-01-03 | 2007-01-03 |  | 144d |  |  |  |
| 58 | 6.2 | Test | 1d? | 2007-01-03 | 2007-01-03 |  | 144d |  |  |  |

| ID | WBS | Task | Duration | Start | Finish | Total slack | Resources | Work |
| --- | --- | --- | --- | --- | --- | --- | --- | --- |
| 60 | 7 | **Documentation** | 1d? | 2007-01-03 | 2007-01-03 | 144d |  | 24h |
| 61 | 7.1 | **O&M Manual** | 1d? | 2007-01-03 | 2007-01-03 | 144d |  | 24h |
| 62 | 7.1.1 | UW | 1d? | 2007-01-03 | 2007-01-03 | 144d | UW | 8h |
| 63 | 7.1.2 | WHOI | 1d? | 2007-01-03 | 2007-01-03 | 144d | WHOI | 8h |
| 64 | 7.1.3 | MBARI | 1d? | 2007-01-03 | 2007-01-03 | 144d | MBARI | 8h |
