# MARS-Dec20-2007

Schedule from MS Project, 2007-12-21 to 2008-01-31, A marks actual dates.
MBARI

## Calendars

- Standard: Mon-Fri 08:00-12:00, 13:00-17:00; Sat-Sun off. Exceptions (off unless hours are given): 2007-12-24 to 2007-12-25, 2008-01-01.

## Resources

| Resource |
| --- |
| Ken |
| Ed |
| Craig |
| Gene |
| Larry |
| Kim |
| Facilities |
| Jose |
| Tom |
| Greg |
| Pete |
| MV |
| LV |

## Schedule

| ID | WBS | Task | Duration | Start | Finish | Predecessors | Complete | Remaining | Total slack | Free slack | Constraint | Deadline | Resources | Work | Actual work |
| --- | --- | --- | --- | --- | --- | --- | --- | --- | --- | --- | --- | --- | --- | --- | --- |
| 1 | 1 | **LV System Closeup** | 23.35d | 2007-12-21 A | 2008-01-28 |  | 6% | 21.92d | 2.75d |  |  |  |  | 145.6h | 8h |
| 2 | 1.1 | **Dry end** | 5.25d | 2008-01-21 | 2008-01-28 |  |  |  | 2.75d |  |  |  |  | 7.2h |  |
| 3 | 1.1.1 | Install o-rings | 0.3d | 2008-01-21 | 2008-01-21 |  |  |  | 2.75d | 0d |  |  | Ken | 2.4h |  |
| 4 | 1.1.2 | Verify operations | 0.1d | 2008-01-21 | 2008-01-21 | 3 |  |  | 2.75d | 0d |  |  | Ken | 0.8h |  |
| 5 | 1.1.3 | Workmanship review | 0.5d | 2008-01-21 | 2008-01-28 | 4 |  |  | 2.75d |  |  |  | Ken; Gene | 4h |  |
| 6 | 1.2 | **Wet end** | 14.29d | 2007-12-21 A | 2008-01-15 |  | 16% | 12.08d | 11.81d |  |  |  |  | 54.4h | 8h |
| 7 | 1.2.1 | Build up resistor bank | 1d | 2007-12-21 | 2007-12-21 |  |  |  | 0d |  |  |  | Gene | 8h |  |
| 8 | 1.2.2 | Duplicate flash disk | 0.5d | 2007-12-27 | 2007-12-27 |  |  |  | 23.1d |  |  |  | Craig | 4h |  |
| 9 | 1.2.3 | Swap in flight CPU (104) | 0.5d | 2007-12-21 A | 2007-12-21 A |  | 100% |  |  |  | start no earlier than 2007-12-21 |  | Craig | 4h | 4h |
| 10 | 1.2.4 | Get Kevin's docs in O&M manual | 0.1d | 2007-12-28 | 2007-12-28 |  |  |  | 23d |  |  |  | Craig | 0.8h |  |
| 11 | 1.2.5 | Install pc104 connector stops | 0.5d | 2007-12-21 A | 2007-12-21 A | 9 | 100% |  |  |  | start no earlier than 2007-12-21 |  | Craig | 4h | 4h |
| 12 | 1.2.6 | Install tie rods | 0.1d | 2007-12-21 | 2007-12-21 | 11 |  |  | 1.4d | 0d |  |  | Ken; LV | 1.6h |  |
| 13 | 1.2.7 | Resister Design Verification | 0.5d | 2007-12-21 | 2007-12-26 | 12 |  |  | 1.4d | 0d |  |  | Ed; Ken; LV; MV | 16h |  |
| 14 | 1.2.8 | Install resistor bank | 1d | 2007-12-26 | 2007-12-27 | 7, 13 |  |  | 0.5d | 0d |  | 2007-12-27 | Ken; Tom; LV | 10h |  |
| 15 | 1.2.9 | Verify stability | 0.5d | 2007-12-27 | 2007-12-27 | 14 |  |  | 16.81d | 0d |  |  |  |  |  |
| 16 | 1.2.10 | Route comms cables | 1d | 2007-12-28 | 2007-12-28 | 15 |  |  | 16.81d | 0d |  |  |  |  |  |
| 17 | 1.2.11 | Workmanship review | 0.5d | 2007-12-31 | 2008-01-04 | 16 |  |  | 16.81d | 0d |  |  | Ken; Gene; LV | 4h |  |
| 18 | 1.2.12 | Verify operation | 0.25d | 2008-01-04 | 2008-01-15 | 17 |  |  | 11.81d |  |  |  | Ken; LV | 2h |  |
| 19 | 1.3 | **Open System testing** | 4.67d | 2007-12-21 | 2007-12-31 |  |  |  | 4.81d | 0d |  |  |  | 32h |  |
| 20 | 1.3.1 | Quick and dirty dyno test | 0.33d | 2007-12-21 | 2007-12-21 |  |  |  | 8.11d | 0d |  |  | Ed; MV; LV | 8h |  |
| 21 | 1.3.2 | Test 2nd 10 kV PS | 0.53d | 2007-12-21 | 2007-12-26 | 20 |  |  | 8.11d |  |  |  | Ed; MV | 8h |  |
| 22 | 1.3.3 | dry run system test | 1.6d | 2007-12-21 | 2007-12-31 |  |  |  | 4.81d | 0d |  |  | Gene; LV; MV | 16h |  |
| 23 | 1.4 | **Close and Fill** | 8.79d | 2007-12-21 | 2008-01-07 |  |  |  | 4.15d |  |  |  |  | 40h |  |
| 24 | 1.4.1 | Filter FC77 | 3d | 2007-12-21 | 2007-12-28 |  |  |  | 4.15d | 0.82d |  |  | Ken | 24h |  |
| 25 | 1.4.2 | close and fill | 2d | 2007-12-31 | 2008-01-07 | 24, 19 |  |  | 4.81d |  |  |  | Gene; LV | 16h |  |

| ID | WBS | Task | Type | Duration | Start | Finish | Predecessors | Total slack | Free slack | Resources | Work |
| --- | --- | --- | --- | --- | --- | --- | --- | --- | --- | --- | --- |
| 26 | 1.5 | **Closed system testing** |  | 1.5d | 2008-01-14 | 2008-01-15 |  | 0.6d | 0d |  | 12h |
| 27 | 1.5.1 | Operational check |  | 0.5d | 2008-01-14 | 2008-01-14 | 23 | 0.6d | 0d | Ken | 4h |
| 28 | 1.5.2 | system test |  | 1d | 2008-01-14 | 2008-01-15 | 27 | 0.6d |  | Gene | 8h |
| 29 | 2 | Build node |  | 1d | 2008-01-15 | 2008-01-16 | 26 | 0.6d |  | Ken; Gene; Larry | 24h |
| 30 | 3 | **Build Test Tank MV Rack** |  | 16.1d | 2007-12-21 | 2008-01-17 |  | 5d |  |  | 96h |
| 31 | 3.1 | **Design** |  | 2d | 2007-12-31 | 2008-01-03 | 22 | 6.93d | 0d | Ed | 16h |
| 32 | 3.1.1 | **Switching/grounding circuit** |  | 1d | 2007-12-31 | 2008-01-02 |  | 7.93d |  |  |  |
| 33 | 3.1.1.1 | interlocks, lights, etc |  | 1d | 2007-12-31 | 2008-01-02 |  | 7.93d |  |  |  |
| 34 | 3.1.2 | rack wiring |  | 2d | 2007-12-31 | 2008-01-03 |  | 6.93d |  |  |  |
| 35 | 3.2 | Artificial line shelf |  | 2d | 2007-12-21 | 2008-01-04 |  | 18.43d |  | Gene; Larry | 16h |
| 36 | 3.3 | Build up and wire rack |  | 1.67d | 2008-01-03 | 2008-01-14 | 31 | 2.12d |  | Ken; Tom | 24h |
| 37 | 3.4 | Sea water ground plates |  | 1d | 2008-01-08 | 2008-01-09 |  | 5.31d |  | Gene | 8h |
| 38 | 3.5 | **Fiber run B to D** |  | 16.1d | 2007-12-21 | 2008-01-17 |  | 0d |  |  | 32h |
| 39 | 3.5.1 | Install building anchor points |  | 1d | 2007-12-21 | 2007-12-21 |  | 5d | 3d | Greg | 8h |
| 40 | 3.5.2 | Run cable |  | 1d | 2008-01-07 | 2008-01-08 | 39 | 2.21d | 0d | Gene | 8h |
| 41 | 3.5.3 | Terminate cable |  | 1d | 2008-01-08 | 2008-01-09 | 40 | 2.21d |  | Jose | 8h |
| 42 | 3.5.4 | Test |  | 1d | 2008-01-14 | 2008-01-17 | 41 | 0d |  | Ken | 8h |
| 43 | 4 | **Tank testing** |  | 7d | 2008-01-17 | 2008-01-28 | 29, 36, 37, 38 | 0d |  |  | 72h |
| 44 | 4.1 | Build up test system |  | 2d | 2008-01-17 | 2008-01-21 |  | 0d |  | Gene; Ken | 32h |
| 45 | 4.2 | Test |  | 5d | 2008-01-21 | 2008-01-28 | 44 | 0d |  | Gene | 40h |
| 46 | 5 | **End of Island** |  | 25.1d | 2007-12-21 | 2008-01-30 |  | 0d |  |  | 104h |
| 47 | 5.1 | Ground plate and wiring |  | 1d | 2008-01-02 | 2008-01-14 |  | 11.29d |  | Ken | 8h |
| 48 | 5.2 | Build up DCS rack |  | 5.32d | 2007-12-21 | 2008-01-03 |  | 18.43d |  | Ken; Gene; Pete; Craig | 64h |
| 49 | 5.3 | Rebuild MV rack |  | 2d | 2008-01-28 | 2008-01-30 | 43 | 0d |  | Ken; Tom | 32h |
| 50 | 6 | MOB |  | 1d | 2008-01-28 | 2008-01-29 | 45 | 1d |  | Craig | 8h |
| 51 | 7 | Deployment | milestone | 1d | 2008-01-30 | 2008-01-31 | 50, 46 | 0d |  | Craig | 8h |
