# MARS-Dec21-2007

Schedule from MS Project, 2007-12-21 to 2008-01-29, A marks actual dates.
MBARI

## Calendars

- Standard: Mon-Fri 08:00-12:00, 13:00-17:00; Sat-Sun off. Exceptions (off unless hours are given): 2007-12-24 to 2007-12-25, 2008-01-01.

## Resources

| Resource |
| --- |
| Ken |
| Ed |
| Craig |
| Gene |
| Larry |
| Kim |
| Facilities |
| Jose |
| Tom |
| Greg |
| Pete |
| MV |
| LV |
| CraigCraig |
| All |
| Bill |

## Schedule

| ID | WBS | Task | Duration | Start | Finish | Predecessors | Complete | Remaining | Total slack | Free slack | Constraint | Deadline | Resources | Work | Actual work |
| --- | --- | --- | --- | --- | --- | --- | --- | --- | --- | --- | --- | --- | --- | --- | --- |
| 1 | 1 | **LV System Closeup** | 9.62d | 2007-12-21 A | 2008-01-08 |  | 8% | 8.9d | 14.88d |  |  |  |  | 144.27h | 8h |
| 2 | 1.1 | **Dry end** | 2.02d | 2007-12-21 | 2007-12-27 |  |  |  | 9.47d |  |  |  |  |  |  |
| 3 | 1.1.1 | Install o-rings | 0.3d | 2007-12-21 | 2007-12-21 |  |  |  | 9.47d | 0d |  |  |  |  |  |
| 4 | 1.1.2 | Verify operations | 0.1d | 2007-12-21 | 2007-12-21 | 3 |  |  | 9.47d | 0d |  |  |  |  |  |
| 5 | 1.1.3 | Workmanship review | 0.5d | 2007-12-21 | 2007-12-27 | 4 |  |  | 9.47d | 7.6d |  |  |  |  |  |
| 6 | 1.2 | **Wet end** | 5.62d | 2007-12-21 A | 2008-01-02 |  | 12% | 4.95d | 18.88d |  |  |  |  | 89.6h | 8h |
| 7 | 1.2.1 | Build up resistor bank | 1d | 2007-12-21 | 2007-12-21 |  |  |  | -1.5d | 0d |  |  | Gene | 8h |  |
| 8 | 1.2.2 | Duplicate flash disk | 0.5d | 2007-12-28 | 2007-12-28 |  |  |  | 20.83d |  |  |  | Craig | 4h |  |
| 9 | 1.2.3 | Swap in flight CPU (104) | 0.5d | 2007-12-21 A | 2007-12-21 A |  | 100% |  |  |  | start no earlier than 2007-12-21 |  | Craig | 4h | 4h |
| 10 | 1.2.4 | Install pc104 connector stops | 0.5d | 2007-12-21 A | 2007-12-21 A | 9 | 100% |  |  |  | start no earlier than 2007-12-21 |  | Craig | 4h | 4h |
| 11 | 1.2.5 | Install tie rods | 0.2d | 2007-12-21 | 2007-12-21 | 10 |  |  | -1.2d | 0d |  |  | LV | 1.6h |  |
| 12 | 1.2.6 | Resister Design Verification | 2d | 2007-12-21 | 2007-12-26 |  |  |  | -2.5d | 0d |  |  | Ed | 16h |  |
| 13 | 1.2.7 | Install resistor bank, route comm cables | 2.5d | 2007-12-27 | 2007-12-31 | 7, 12, 11 |  |  | -2.5d | 0d |  | 2007-12-27 | Ken; Tom; LV | 42h |  |
| 14 | 1.2.8 | Verify stability | 0.5d | 2007-12-31 | 2007-12-31 | 13 |  |  | 0.25d | 0d |  |  | Ed | 4h |  |
| 15 | 1.2.9 | Workmanship review | 0.5d | 2008-01-02 | 2008-01-02 | 14 |  |  | 0.25d | 0d |  |  | Craig | 4h |  |
| 16 | 1.2.10 | Verify operation | 0.12d | 2008-01-02 | 2008-01-02 | 15 |  |  | 0.25d | 0d |  |  | Ken; LV | 2h |  |
| 17 | 1.3 | **Open System testing** | 4d | 2008-01-02 | 2008-01-08 |  |  |  | 0.25d | 0d |  |  |  | 54.67h |  |
| 18 | 1.3.1 | Quick and dirty dyno test | 0.5d | 2008-01-02 | 2008-01-03 | 16 |  |  | 0.25d | 0d |  |  | Ed; MV; LV | 12h |  |
| 19 | 1.3.2 | Test 2nd 10 kV PS | 0.5d | 2008-01-03 | 2008-01-03 | 18 |  |  | 0.25d | 0d |  |  | Ed; MV | 8h |  |
| 20 | 1.3.3 | dry run system test | 3d | 2008-01-03 | 2008-01-08 | 19 |  |  | 0.25d | 0d |  |  | Gene; LV; MV | 34.67h |  |
| 21 | 2 | Filter FC77 | 3d | 2007-12-21 | 2007-12-27 |  |  |  | 8.5d | 6.62d |  |  |  |  |  |
| 22 | 3 | close and fill | 1.5d | 2008-01-08 | 2008-01-10 | 17, 5, 21, 20 |  |  | 1.88d |  |  |  | Gene; LV | 24h |  |
| 23 | 4 | **Closed system testing** | 1.5d | 2008-01-14 | 2008-01-15 |  |  |  | 0d |  |  |  |  | 12h |  |
| 24 | 4.1 | Operational check | 0.5d | 2008-01-14 | 2008-01-14 | 22 |  |  | 0d |  |  |  | Ken | 4h |  |
| 25 | 4.2 | system test | 1d | 2008-01-14 | 2008-01-15 | 24 |  |  | 0d |  |  |  | Gene | 8h |  |
| 26 | 5 | Build node | 1d | 2008-01-15 | 2008-01-16 | 23 |  |  | 0d |  |  |  | Ken; Gene; Larry | 24h |  |

| ID | WBS | Task | Type | Duration | Start | Finish | Predecessors | Total slack | Free slack | Resources | Work |
| --- | --- | --- | --- | --- | --- | --- | --- | --- | --- | --- | --- |
| 27 | 6 | **Build Test Tank MV Rack** |  | 15.25d | 2007-12-21 | 2008-01-16 |  | 7d |  |  | 104h |
| 28 | 6.1 | **Design** |  | 2.62d | 2008-01-08 | 2008-01-11 | 20 | 0.25d | 0d |  | 24h |
| 29 | 6.1.1 | Switching/grounding circuit |  | 1d | 2008-01-08 | 2008-01-09 |  | 1.88d |  | Ed | 8h |
| 30 | 6.1.2 | rack wiring |  | 2d | 2008-01-08 | 2008-01-11 |  | 0.25d |  | Ed | 16h |
| 31 | 6.2 | Artificial line shelf |  | 2d | 2007-12-21 | 2007-12-26 |  | 22.5d |  | Larry | 16h |
| 32 | 6.3 | Build up and wire rack |  | 3d | 2008-01-11 | 2008-01-16 | 28 | 0.25d |  | Tom | 24h |
| 33 | 6.4 | Sea water ground plates |  | 1d | 2008-01-03 | 2008-01-10 |  | 4d |  | Gene | 8h |
| 34 | 6.5 | **Fiber run B to D** |  | 12.5d | 2007-12-21 | 2008-01-11 |  | 3d |  |  | 32h |
| 35 | 6.5.1 | Install building anchor points |  | 1d | 2007-12-21 | 2007-12-21 |  | 7d | 4d | Greg | 8h |
| 36 | 6.5.2 | Run cable |  | 1d | 2008-01-02 | 2008-01-02 | 35 | 3d | 0d | Gene | 8h |
| 37 | 6.5.3 | Terminate cable |  | 1d | 2008-01-03 | 2008-01-03 | 36 | 3d | 0d | Jose | 8h |
| 38 | 6.5.4 | Test |  | 1d | 2008-01-10 | 2008-01-11 | 37 | 3d |  | Gene | 8h |
| 39 | 7 | **Tank testing** |  | 6d | 2008-01-16 | 2008-01-24 | 26, 32, 33, 34 | 0d |  |  | 96h |
| 40 | 7.1 | Build up test system |  | 2d | 2008-01-16 | 2008-01-18 |  | 0d |  | Gene; Ken | 32h |
| 41 | 7.2 | Test |  | 4d | 2008-01-18 | 2008-01-24 | 40 | 0d |  | Gene; All | 64h |
| 42 | 8 | **End of Island** |  | 23.5d | 2007-12-21 | 2008-01-28 |  | 0d |  |  | 104.67h |
| 43 | 8.1 | Ground plate and wiring |  | 1d | 2007-12-28 | 2007-12-28 |  | 19.5d |  | Ken | 8h |
| 44 | 8.2 | Build up DCS rack |  | 3.17d | 2007-12-21 | 2007-12-28 |  | 20.33d |  | Ken; Pete; Craig | 64.67h |
| 45 | 8.3 | Rebuild MV rack |  | 2d | 2008-01-24 | 2008-01-28 | 39 | 0d |  | Ken; Tom | 32h |
| 46 | 9 | MOB |  | 1d | 2008-01-24 | 2008-01-25 | 41 | 1d |  | Craig | 8h |
| 47 | 10 | Deployment | milestone | 1d | 2008-01-28 | 2008-01-29 | 46, 42 | 0d |  | Craig | 8h |
