# MARS-Dec21-2007

Schedule from MS Project, 2007-12-21 to 2008-02-20, A marks actual dates.
MBARI

## Calendars

- Standard: Mon-Fri 08:00-12:00, 13:00-17:00; Sat-Sun off. Exceptions (off unless hours are given): 2007-12-24 to 2007-12-25, 2008-01-01.

## Resources

| Resource |
| --- |
| Ken |
| Ed |
| Craig |
| Gene |
| Larry |
| Kim |
| Facilities |
| Jose |
| Tom |
| Greg |
| Pete |
| MV |
| LV |
| CraigCraig |
| All |
| Bill |

## Schedule

| ID | WBS | Task | Duration | Start | Finish | Predecessors | Complete | Remaining | Total slack | Free slack | Constraint | Deadline | Resources | Work | Actual work |
| --- | --- | --- | --- | --- | --- | --- | --- | --- | --- | --- | --- | --- | --- | --- | --- |
| 1 | 1 | **LV System Closeup** | 11.62d | 2007-12-21 08:00 A | 2008-01-10 14:00 |  | 8% | 10.75d | 29d |  |  |  |  | 188.53h | 8h |
| 2 | 1.1 | **Dry end** | 8.72d | 2007-12-21 08:00 | 2008-01-07 14:48 |  |  |  | 16.9d |  |  |  |  | 8.27h |  |
| 3 | 1.1.1 | Install o-rings | 0.3d | 2007-12-21 08:00 | 2007-12-21 10:24 |  |  |  | 17.7d | 1.7d |  |  |  |  |  |
| 4 | 1.1.2 | Verify operations | 0.1d | 2008-01-07 09:00 | 2008-01-07 09:48 | 3 |  |  | 16.9d | 0d | start no earlier than 2007-12-27 08:00 |  | Craig; LV | 1.6h |  |
| 5 | 1.1.3 | Workmanship review | 0.5d | 2008-01-07 09:48 | 2008-01-07 14:48 | 4 |  |  | 16.9d | 2.9d |  |  | Craig; LV | 6.67h |  |
| 6 | 1.2 | **Wet end** | 7.62d | 2007-12-21 08:00 A | 2008-01-04 14:00 |  | 12% | 6.71d | 33d |  |  |  |  | 125.6h | 8h |
| 7 | 1.2.1 | Build up resistor bank | 1d | 2007-12-21 08:00 | 2007-12-21 17:00 |  |  |  | -1.5d | 0d |  |  | Gene | 8h |  |
| 8 | 1.2.2 | Duplicate flash disk | 0.5d | 2007-12-21 13:00 | 2007-12-21 17:00 |  |  |  | 39.62d |  |  |  | Craig | 4h |  |
| 9 | 1.2.3 | Swap in flight CPU (104) | 0.5d | 2007-12-21 08:00 A | 2007-12-21 12:00 A |  | 100% |  |  |  | start no earlier than 2007-12-21 08:00 |  | Craig | 4h | 4h |
| 10 | 1.2.4 | Install pc104 connector stops | 0.5d | 2007-12-21 08:00 A | 2007-12-21 12:00 A | 9 | 100% |  |  |  | start no earlier than 2007-12-21 08:00 |  | Craig | 4h | 4h |
| 11 | 1.2.5 | Install tie rods | 0.2d | 2007-12-21 13:00 | 2007-12-21 14:36 | 10 |  |  | -1.2d | 0d |  |  | LV | 1.6h |  |
| 12 | 1.2.6 | Resister Design Verification | 2d | 2007-12-27 08:00 | 2007-12-28 17:00 |  |  |  | -4.5d | 0d | start no earlier than 2007-12-27 08:00 |  | Ed; LV; MV | 44h |  |
| 13 | 1.2.7 | Install resistor bank, route comm cables | 2.5d | 2007-12-31 08:00 | 2008-01-03 12:00 | 7, 12, 11 |  |  | -4.5d | 0d |  | 2007-12-27 17:00 | Ken; Tom; LV | 42h |  |
| 14 | 1.2.8 | Verify stability | 0.5d | 2008-01-03 13:00 | 2008-01-03 17:00 | 13 |  |  | 0d |  |  |  | Ed; LV | 8h |  |
| 15 | 1.2.9 | Workmanship review | 0.5d | 2008-01-04 08:00 | 2008-01-04 12:00 | 14 |  |  | 0d |  |  |  | Craig; LV | 8h |  |
| 16 | 1.2.10 | Verify operation | 0.12d | 2008-01-04 13:00 | 2008-01-04 14:00 | 15 |  |  | 0d |  |  |  | Ken; LV | 2h |  |
| 17 | 1.3 | **Open System testing** | 4d | 2008-01-04 14:00 | 2008-01-10 14:00 |  |  |  | 0d |  |  |  |  | 54.67h |  |
| 18 | 1.3.1 | Quick and dirty dyno test | 0.5d | 2008-01-04 14:00 | 2008-01-07 09:00 | 16 |  |  | 0d |  |  |  | Ed; MV; LV | 12h |  |
| 19 | 1.3.2 | Test 2nd 10 kV PS | 0.5d | 2008-01-07 09:00 | 2008-01-07 14:00 | 18 |  |  | 0d |  |  |  | Ed; MV | 8h |  |
| 20 | 1.3.3 | dry run system test | 3d | 2008-01-07 14:00 | 2008-01-10 14:00 | 19 |  |  | 0d |  |  |  | Gene; LV; MV | 34.67h |  |
| 21 | 2 | **Filter FC77** | 3d | 2008-01-02 08:00 | 2008-01-04 17:00 |  |  |  | 17.62d |  |  |  |  | 4h |  |
| 22 | 2.1 | Setup | 0.5d | 2008-01-02 08:00 | 2008-01-02 12:00 |  |  |  | 17.62d | 0d |  |  | Gene | 4h |  |
| 23 | 2.2 | Run | 2.5d | 2008-01-02 13:00 | 2008-01-04 17:00 | 22 |  |  | 17.62d | 3.62d |  |  |  |  |  |
| 24 | 3 | close and fill | 1.5d | 2008-01-10 14:00 | 2008-01-14 09:00 | 17, 5, 20, 23 |  |  | 14d | 0d |  |  | Gene; LV | 24h |  |

| ID | WBS | Task | Duration | Start | Finish | Predecessors | Total slack | Free slack | Constraint | Resources | Work |
| --- | --- | --- | --- | --- | --- | --- | --- | --- | --- | --- | --- |
| 25 | 4 | **Closed system testing** | 1.5d | 2008-01-14 09:00 | 2008-01-15 14:00 |  | 14d | 0d |  |  | 12h |
| 26 | 4.1 | Operational check | 0.5d | 2008-01-14 09:00 | 2008-01-14 14:00 | 24 | 14d | 0d |  | Ken | 4h |
| 27 | 4.2 | system test | 1d | 2008-01-14 14:00 | 2008-01-15 14:00 | 26 | 14d |  |  | Gene | 8h |
| 28 | 5 | Build node | 1d | 2008-01-15 14:00 | 2008-01-16 14:00 | 25 | 14d |  |  | Ken; Gene; Larry | 24h |
| 29 | 6 | **Build Test Tank MV Rack** | 29.62d | 2007-12-21 08:00 | 2008-02-05 14:00 |  | 11d |  |  |  | 160h |
| 30 | 6.1 | **Design** | 15d | 2008-01-10 14:00 | 2008-01-31 14:00 | 20 | 0d |  |  |  | 80h |
| 31 | 6.1.1 | Switching/grounding circuit | 5d | 2008-01-10 14:00 | 2008-01-17 14:00 |  | 0d |  |  | Ed | 40h |
| 32 | 6.1.2 | rack wiring | 5d | 2008-01-17 14:00 | 2008-01-24 14:00 | 31 | 0d |  |  | Ed | 40h |
| 33 | 6.1.3 | Parts procurement | 1w | 2008-01-24 14:00 | 2008-01-31 14:00 | 32 | 0d |  |  |  |  |
| 34 | 6.2 | Artificial line shelf | 2d | 2008-01-02 08:00 | 2008-01-03 17:00 |  | 33.62d |  | start no earlier than 2008-01-02 08:00 | Larry | 16h |
| 35 | 6.3 | Build up and wire rack | 3d | 2008-01-31 14:00 | 2008-02-05 14:00 | 30, 32, 33 | 0d |  |  | Tom | 24h |
| 36 | 6.4 | Sea water ground plates | 1d | 2008-01-03 13:00 | 2008-01-04 12:00 |  | 22.12d |  |  | Gene | 8h |
| 37 | 6.5 | **Fiber run B to D** | 8.5d | 2007-12-21 08:00 | 2008-01-07 12:00 |  | 21.12d |  |  |  | 32h |
| 38 | 6.5.1 | Install building anchor points | 1d | 2007-12-21 08:00 | 2007-12-21 17:00 |  | 25.12d | 4d |  | Greg | 8h |
| 39 | 6.5.2 | Run cable | 1d | 2008-01-02 13:00 | 2008-01-03 12:00 | 38 | 21.12d | 0d |  | Gene | 8h |
| 40 | 6.5.3 | Terminate cable | 1d | 2008-01-03 13:00 | 2008-01-04 12:00 | 39 | 21.12d | 0d |  | Jose | 8h |
| 41 | 6.5.4 | Test | 1d | 2008-01-04 13:00 | 2008-01-07 12:00 | 40 | 21.12d |  |  | Gene | 8h |
| 42 | 7 | **Tank testing** | 6d | 2008-02-05 14:00 | 2008-02-13 14:00 | 28, 35, 36, 37 | 0d |  |  |  | 160h |
| 43 | 7.1 | Build up test system | 2d | 2008-02-05 14:00 | 2008-02-07 14:00 |  | 0d |  |  | Gene; Ken | 32h |
| 44 | 7.2 | Test | 4d | 2008-02-07 14:00 | 2008-02-13 14:00 | 43 | 0d |  |  | Gene; All; MV; LV | 128h |
| 45 | 8 | **End of Island** | 36.02d | 2007-12-27 13:48 | 2008-02-18 14:00 |  | 0d |  |  |  | 126.67h |
| 46 | 8.1 | Ground plate and wiring | 1d | 2008-01-03 14:36 | 2008-01-04 14:36 |  | 30.93d |  | start no earlier than 2007-12-27 08:00 | Ken | 8h |
| 47 | 8.2 | Build up DCS rack | 3.5d | 2007-12-27 13:48 | 2008-01-03 14:36 |  | 31.93d |  | start no earlier than 2007-12-27 08:00 | Ken; Pete; Craig | 70.67h |
| 48 | 8.3 | Rebuild MV rack | 3d | 2008-02-13 14:00 | 2008-02-18 14:00 | 42 | 0d |  |  | Ken; Tom | 48h |
| 49 | 9 | MOB | 1d | 2008-02-13 14:00 | 2008-02-14 14:00 | 44 | 2d |  |  | Craig | 8h |
| 50 | 10 | Deployment | 2d | 2008-02-18 14:00 | 2008-02-20 14:00 | 49, 45 | 0d |  |  | Craig | 16h |
