# MARS-Dec21-2007

Schedule from MS Project, 2007-12-21 to 2008-02-08, A marks actual dates.
MBARI

## Calendars

- Standard: Mon-Fri 08:00-12:00, 13:00-17:00; Sat-Sun off. Exceptions (off unless hours are given): 2007-12-24 to 2007-12-25, 2008-01-01.

## Resources

| Resource |
| --- |
| Ken |
| Ed |
| Craig |
| Gene |
| Larry |
| Kim |
| Facilities |
| Jose |
| Tom |
| Greg |
| Pete |
| MV |
| LV |
| CraigCraig |
| All |
| Bill |

## Schedule

| ID | WBS | Task | Duration | Start | Finish | Predecessors | Complete | Remaining | Total slack | Free slack | Constraint | Deadline | Resources | Work | Actual work |
| --- | --- | --- | --- | --- | --- | --- | --- | --- | --- | --- | --- | --- | --- | --- | --- |
| 1 | 1 | **LV System Closeup** | 18d | 2007-12-21 A | 2008-01-18 |  | 8% | 16.63d | 15d |  |  |  |  | 186.93h | 8h |
| 2 | 1.1 | **Dry end** | 7.1d | 2007-12-21 | 2008-01-04 |  |  |  | 10.9d |  |  |  |  | 8.27h |  |
| 3 | 1.1.1 | Install o-rings | 0.3d | 2007-12-21 | 2007-12-21 |  |  |  | 11.7d | 1.7d |  |  |  |  |  |
| 4 | 1.1.2 | Verify operations | 0.1d | 2008-01-03 | 2008-01-03 | 3 |  |  | 10.9d | 0d | start no earlier than 2007-12-27 |  | Craig; LV | 1.6h |  |
| 5 | 1.1.3 | Workmanship review | 0.5d | 2008-01-03 | 2008-01-04 | 4 |  |  | 10.9d |  |  |  | Craig; LV | 6.67h |  |
| 6 | 1.2 | **Wet end** | 13.12d | 2007-12-21 A | 2008-01-14 |  | 12% | 11.53d | 19.88d |  |  |  |  | 124h | 8h |
| 7 | 1.2.1 | Build up resistor bank | 1d | 2007-12-21 | 2007-12-21 |  |  |  | -1.5d | 0d |  |  | Gene | 8h |  |
| 8 | 1.2.2 | Duplicate flash disk | 0.5d | 2007-12-21 | 2007-12-21 |  |  |  | 32d |  |  |  | Craig | 4h |  |
| 9 | 1.2.3 | Swap in flight CPU (104) | 0.5d | 2007-12-21 A | 2007-12-21 A |  | 100% |  |  |  | start no earlier than 2007-12-21 |  | Craig | 4h | 4h |
| 10 | 1.2.4 | Install pc104 connector stops | 0.5d | 2007-12-21 A | 2007-12-21 A | 9 | 100% |  |  |  | start no earlier than 2007-12-21 |  | Craig | 4h | 4h |
| 11 | 1.2.5 | Resistor Design Verification | 2d | 2007-12-27 | 2007-12-28 |  |  |  | -4.5d | 0d | start no earlier than 2007-12-27 |  | Ed; LV; MV | 44h |  |
| 12 | 1.2.6 | Install resistor bank, route comm cables, install tie rods | 2.5d | 2007-12-31 | 2008-01-03 | 7, 11 |  |  | -4.5d | 0d |  | 2007-12-27 | Ken; Tom; LV | 42h |  |
| 13 | 1.2.7 | Verify stability | 0.5d | 2008-01-07 | 2008-01-07 | 12 |  |  | 3.5d | 0d |  |  | Ed; LV | 8h |  |
| 14 | 1.2.8 | Workmanship review | 0.5d | 2008-01-08 | 2008-01-08 | 13 |  |  | 3.5d | 0d |  |  | Craig; LV | 8h |  |
| 15 | 1.2.9 | Verify operation | 0.25d | 2008-01-08 | 2008-01-14 | 14 |  |  | 0d |  |  |  | Ken; LV | 2h |  |
| 16 | 1.3 | **Open System testing** | 4d | 2008-01-15 | 2008-01-18 |  |  |  | 0d |  |  |  |  | 54.67h |  |
| 17 | 1.3.1 | Quick and dirty dyno test | 0.5d | 2008-01-15 | 2008-01-15 | 15 |  |  | 0d |  |  |  | Ed; MV; LV | 12h |  |
| 18 | 1.3.2 | Test 2nd 10 kV PS | 0.5d | 2008-01-15 | 2008-01-15 | 17 |  |  | 0d |  |  |  | Ed; MV | 8h |  |
| 19 | 1.3.3 | dry run system test | 3d | 2008-01-16 | 2008-01-18 | 18 |  |  | 0d |  |  |  | Gene; LV; MV | 34.67h |  |
| 20 | 2 | **Filter FC77** | 3d | 2008-01-02 | 2008-01-04 |  |  |  | 10d |  |  |  |  | 4h |  |
| 21 | 2.1 | Setup | 0.5d | 2008-01-02 | 2008-01-02 |  |  |  | 10d | 0d |  |  | Gene | 4h |  |
| 22 | 2.2 | Run | 2.5d | 2008-01-02 | 2008-01-04 | 21 |  |  | 10d |  |  |  |  |  |  |
| 23 | 3 | close and fill | 1.5d | 2008-01-21 | 2008-01-22 | 16, 5, 19, 22 |  |  | 0d |  |  |  | Gene; LV | 24h |  |
| 24 | 4 | **Closed system testing** | 1.5d | 2008-01-22 | 2008-01-23 |  |  |  | 0d |  |  |  |  | 12h |  |
| 25 | 4.1 | Operational check | 0.5d | 2008-01-22 | 2008-01-22 | 23 |  |  | 0d |  |  |  | Ken | 4h |  |
| 26 | 4.2 | system test | 1d | 2008-01-23 | 2008-01-23 | 25 |  |  | 0d |  |  |  | Gene | 8h |  |
| 27 | 5 | Build node | 1d | 2008-01-24 | 2008-01-24 | 24 |  |  | 0d |  |  |  | Ken; Gene; Larry | 24h |  |

| ID | WBS | Task | Duration | Start | Finish | Predecessors | Total slack | Free slack | Constraint | Resources | Work |
| --- | --- | --- | --- | --- | --- | --- | --- | --- | --- | --- | --- |
| 28 | 6 | **Build Test Tank MV Rack** | 22d | 2007-12-21 | 2008-01-24 |  | 4d |  |  |  | 156h |
| 29 | 6.1 | **Design** | 15d | 2007-12-31 | 2008-01-21 |  | 0d |  | start no earlier than 2007-12-28 |  | 76h |
| 30 | 6.1.1 | Switching/grounding circuit | 5d | 2007-12-31 | 2008-01-07 |  | 0d |  |  | Ed | 36h |
| 31 | 6.1.2 | rack wiring | 5d | 2008-01-08 | 2008-01-14 | 30 | 0d |  |  | Ed | 40h |
| 32 | 6.1.3 | Parts procurement | 1w | 2008-01-15 | 2008-01-21 | 31 | 0d |  |  |  |  |
| 33 | 6.2 | Artificial line shelf | 2d | 2008-01-02 | 2008-01-03 |  | 26d |  | start no earlier than 2008-01-02 | Larry | 16h |
| 34 | 6.3 | Build up and wire rack | 3d | 2008-01-22 | 2008-01-24 | 29, 31, 32 | 0d |  |  | Tom | 24h |
| 35 | 6.4 | Sea water ground plates | 1d | 2008-01-03 | 2008-01-04 |  | 14.5d |  |  | Gene | 8h |
| 36 | 6.5 | **Fiber run B to D** | 8.5d | 2007-12-21 | 2008-01-07 |  | 13.5d |  |  |  | 32h |
| 37 | 6.5.1 | Install building anchor points | 1d | 2007-12-21 | 2007-12-21 |  | 18d | 4d |  | Greg | 8h |
| 38 | 6.5.2 | Run cable | 1d | 2008-01-02 | 2008-01-03 | 37 | 13.5d | 0d |  | Gene | 8h |
| 39 | 6.5.3 | Terminate cable | 1d | 2008-01-03 | 2008-01-04 | 38 | 13.5d | 0d |  | Jose | 8h |
| 40 | 6.5.4 | Test | 1d | 2008-01-04 | 2008-01-07 | 39 | 13.5d |  |  | Gene | 8h |
| 41 | 7 | **Tank testing** | 6d | 2008-01-25 | 2008-02-01 | 27, 34, 35, 36 | 0d |  |  |  | 160h |
| 42 | 7.1 | Build up test system | 2d | 2008-01-25 | 2008-01-28 |  | 0d |  |  | Gene; Ken | 32h |
| 43 | 7.2 | Test | 4d | 2008-01-29 | 2008-02-01 | 42 | 0d |  |  | Gene; All; MV; LV | 128h |
| 44 | 8 | **End of Island** | 28.4d | 2007-12-27 | 2008-02-06 |  | 0d |  |  |  | 126.67h |
| 45 | 8.1 | Ground plate and wiring | 1d | 2008-01-03 | 2008-01-04 |  | 23.3d |  | start no earlier than 2007-12-27 | Ken | 8h |
| 46 | 8.2 | Build up DCS rack | 3.5d | 2007-12-27 | 2008-01-03 |  | 24.3d |  | start no earlier than 2007-12-27 | Ken; Pete; Craig | 70.67h |
| 47 | 8.3 | Rebuild MV rack | 3d | 2008-02-04 | 2008-02-06 | 41 | 0d |  |  | Ken; Tom | 48h |
| 48 | 9 | MOB | 1d | 2008-02-04 | 2008-02-04 | 43 | 2d |  |  | Craig | 8h |
| 49 | 10 | Deployment | 2d | 2008-02-07 | 2008-02-08 | 48, 44 | 0d |  |  | Craig | 16h |
