# MARS-Dec21-2007

Schedule from MS Project, 2007-12-21 to 2008-02-20, A marks actual dates.
MBARI

## Calendars

- Standard: Mon-Fri 08:00-12:00, 13:00-17:00; Sat-Sun off. Exceptions (off unless hours are given): 2007-12-24 to 2007-12-25, 2008-01-01, 2008-01-21.

## Resources

| Resource |
| --- |
| Ken |
| Ed |
| Craig |
| Gene |
| Larry |
| Kim |
| Facilities |
| Jose |
| Tom |
| Greg |
| Pete |
| MV |
| LV |
| CraigCraig |
| All |
| Bill |

## Schedule

| ID | WBS | Task | Duration | Start | Finish | Predecessors | Complete | Remaining | Total slack | Free slack | Constraint | Deadline | Resources | Work | Actual work |
| --- | --- | --- | --- | --- | --- | --- | --- | --- | --- | --- | --- | --- | --- | --- | --- |
| 1 | 1 | **LV System Closeup** | 21d | 2007-12-21 A | 2008-01-24 |  | 39% | 12.77d | 19d |  |  |  |  | 186.93h | 94h |
| 2 | 1.1 | **Dry end** | 7.43d | 2007-12-21 | 2008-01-04 |  |  |  | 17.57d |  |  |  |  | 8.27h |  |
| 3 | 1.1.1 | Install o-rings | 0.3d | 2007-12-21 | 2007-12-21 |  |  |  | 19.6d | 1.7d |  |  |  |  |  |
| 4 | 1.1.2 | Verify operations | 0.2d | 2007-12-27 | 2007-12-31 | 3 |  |  | 17.9d | 0d | start no earlier than 2007-12-27 |  | Craig; LV | 1.6h |  |
| 5 | 1.1.3 | Workmanship review | 0.67d | 2008-01-03 | 2008-01-04 | 4 |  |  | 17.57d | 13.57d |  |  | Craig; LV | 6.67h |  |
| 6 | 1.2 | **Wet end** | 13.06d | 2007-12-21 A | 2008-01-14 |  | 65% | 4.57d | 26.94d |  |  |  |  | 124h | 94h |
| 7 | 1.2.1 | Build up resistor bank | 1d | 2008-01-03 | 2008-01-04 |  |  |  | 32.5d |  |  |  | Gene | 8h |  |
| 8 | 1.2.2 | Duplicate flash disk | 0.5d | 2007-12-21 | 2007-12-21 |  |  |  | 39d |  |  |  | Craig | 4h |  |
| 9 | 1.2.3 | Swap in flight CPU (104) | 0.5d | 2007-12-21 A | 2007-12-21 A |  | 100% |  |  |  | start no earlier than 2007-12-21 |  | Craig | 4h | 4h |
| 10 | 1.2.4 | Install pc104 connector stops | 0.5d | 2007-12-21 A | 2007-12-21 A | 9 | 100% |  |  |  | start no earlier than 2007-12-21 |  | Craig | 4h | 4h |
| 11 | 1.2.5 | Resistor Design Verification | 2d | 2007-12-27 A | 2007-12-28 A |  | 100% |  |  |  | start no earlier than 2007-12-27 |  | Ed; LV; MV | 44h | 44h |
| 12 | 1.2.6 | Install resistor bank, route comm cables, install tie rods | 2.6d | 2007-12-31 A | 2008-01-03 A | 7, 11 | 100% |  |  |  |  | 2007-12-27 | Ken; Tom; LV | 42h | 42h |
| 13 | 1.2.7 | Verify stability | 0.5d | 2008-01-03 | 2008-01-04 | 12 |  |  | 9d | 0d |  |  | Ed; LV | 8h |  |
| 14 | 1.2.8 | Workmanship review | 0.83d | 2008-01-04 | 2008-01-04 | 13 |  |  | 9d | 0d |  |  | Craig; LV | 8h |  |
| 15 | 1.2.9 | Verify operation | 0.18d | 2008-01-04 | 2008-01-14 | 14 |  |  | 4d | 0d |  |  | Ken; LV | 2h |  |
| 16 | 1.3 | **Open System testing** | 7.94d | 2008-01-14 | 2008-01-24 |  |  |  | 4d | 0d |  |  |  | 54.67h |  |
| 17 | 1.3.1 | Quick and dirty dyno test | 1d | 2008-01-14 | 2008-01-18 | 15 |  |  | 4d | 0d |  |  | Ed; MV; LV | 12h |  |
| 18 | 1.3.2 | Test 2nd 10 kV PS | 0.5d | 2008-01-18 | 2008-01-18 | 17 |  |  | 4d | 0d |  |  | Ed; MV | 8h |  |
| 19 | 1.3.3 | dry run system test | 3d | 2008-01-22 | 2008-01-24 | 18 |  |  | 4d | 0d |  |  | Gene; LV; MV | 34.67h |  |
| 20 | 2 | **Filter FC77** | 3d | 2007-12-21 | 2007-12-27 |  |  |  | 22d |  |  |  |  | 4h |  |
| 21 | 2.1 | Setup | 0.5d | 2007-12-21 | 2007-12-21 |  |  |  | 22d | 0d |  |  | Gene | 4h |  |
| 22 | 2.2 | Run | 2.5d | 2007-12-21 | 2007-12-27 | 21 |  |  | 22d | 18d |  |  |  |  |  |
| 23 | 3 | close and fill | 1.5d | 2008-01-25 | 2008-01-28 | 16, 5, 19, 22 |  |  | 4d | 0d |  |  | Gene; LV | 24h |  |
| 24 | 4 | **Closed system testing** | 1.5d | 2008-01-28 | 2008-01-29 |  |  |  | 4d | 0d |  |  |  | 12h |  |
| 25 | 4.1 | Operational check | 0.5d | 2008-01-28 | 2008-01-28 | 23 |  |  | 4d | 0d |  |  | Ken | 4h |  |
| 26 | 4.2 | system test | 1d | 2008-01-29 | 2008-01-29 | 25 |  |  | 4d |  |  |  | Gene | 8h |  |
| 27 | 5 | Build node | 1d | 2008-01-30 | 2008-01-30 | 24 |  |  | 4d |  |  |  | Ken; Gene; Larry | 24h |  |

| ID | WBS | Task | Duration | Start | Finish | Predecessors | Complete | Remaining | Total slack | Constraint | Resources | Work | Actual work |
| --- | --- | --- | --- | --- | --- | --- | --- | --- | --- | --- | --- | --- | --- |
| 28 | 6 | **Build Test Tank MV Rack** | 29d | 2007-12-21 A | 2008-02-05 |  | 17% | 24.17d | 0d |  |  | 168h | 32h |
| 29 | 6.1 | **Switching/grounding circuit** | 14d | 2008-01-11 | 2008-01-31 |  |  |  | 0d |  |  | 88h |  |
| 30 | 6.1.1 | Design | 5d | 2008-01-11 | 2008-01-17 |  |  |  | 0d | start no earlier than 2008-01-11 | Ed | 40h |  |
| 31 | 6.1.2 | Parts procurement | 6d | 2008-01-18 | 2008-01-28 | 30 |  |  | 0d |  |  |  |  |
| 32 | 6.1.3 | Build box and wire | 3d | 2008-01-29 | 2008-01-31 | 31 |  |  | 0d |  | Ed; Tom | 48h |  |
| 33 | 6.2 | Artificial line shelf | 2d | 2008-01-18 | 2008-01-22 |  |  |  | 7d | finish no earlier than 2008-01-22 | Larry | 16h |  |
| 34 | 6.3 | Build up and wire rack | 3d | 2008-02-01 | 2008-02-05 | 33, 29, 47 |  |  | 0d |  | Tom | 24h |  |
| 35 | 6.4 | Sea water ground plates | 1d | 2007-12-21 | 2008-01-02 |  |  |  | 23.5d |  | Gene | 8h |  |
| 36 | 6.5 | **Fiber run B to D** | 8.5d | 2007-12-21 A | 2008-01-07 A |  | 100% |  |  |  |  | 32h | 32h |
| 37 | 6.5.1 | Install building anchor points | 1d | 2007-12-21 A | 2007-12-21 A |  | 100% |  |  |  | Greg | 8h | 8h |
| 38 | 6.5.2 | Run cable | 1d | 2008-01-02 A | 2008-01-03 A | 37 | 100% |  |  |  | Gene | 8h | 8h |
| 39 | 6.5.3 | Terminate cable | 1d | 2008-01-03 A | 2008-01-04 A | 38 | 100% |  |  |  | Jose | 8h | 8h |
| 40 | 6.5.4 | Test | 1d | 2008-01-04 A | 2008-01-07 A | 39 | 100% |  |  |  | Gene | 8h | 8h |
| 41 | 7 | **Tank testing** | 6d | 2008-02-06 | 2008-02-13 | 27, 34, 35, 36 |  |  | 0d |  |  | 160h |  |
| 42 | 7.1 | MOB in test tank area | 2d | 2008-02-06 | 2008-02-07 |  |  |  | 0d |  | Gene; Ken | 32h |  |
| 43 | 7.2 | Test | 4d | 2008-02-08 | 2008-02-13 | 42 |  |  | 0d |  | Gene; All; MV; LV | 128h |  |
| 44 | 8 | **End of Island** | 36d | 2007-12-27 | 2008-02-18 |  |  |  | 0d |  |  | 166.67h |  |
| 45 | 8.1 | Ground plate and wiring | 1d | 2008-01-16 | 2008-01-16 |  |  |  | 22d | start no earlier than 2008-01-16 | Ken | 8h |  |
| 46 | 8.2 | Build up DCS rack | 3.75d | 2007-12-27 | 2008-01-02 |  |  |  | 32.25d | start no earlier than 2007-12-27 | Ken; Pete; Craig | 70.67h |  |
| 47 | 8.3 | rack wiring design | 5d | 2008-01-22 | 2008-01-28 |  |  |  | 12d | start no earlier than 2008-01-16 | Ed | 40h |  |
| 48 | 8.4 | Rebuild MV rack | 3d | 2008-02-14 | 2008-02-18 | 41, 47 |  |  | 0d |  | Ken; Tom | 48h |  |
| 49 | 9 | MOB | 1d | 2008-02-14 | 2008-02-14 | 43 |  |  | 2d |  | Craig | 8h |  |
| 50 | 10 | Deployment | 2d | 2008-02-19 | 2008-02-20 | 49, 44 |  |  | 0d |  | Craig | 16h |  |
